# HB650 CTL v2

Schedule from MS Project, 2020-09-16 to 2021-07-29.

## Calendars

- Standard: Mon-Fri 08:00-12:00, 13:00-17:00; Sat-Sun off.

## Schedule

| ID | WBS | Task | Type | Duration | Start | Finish | Predecessors | Total slack | Free slack | Constraint |
| --- | --- | --- | --- | --- | --- | --- | --- | --- | --- | --- |
| 1 | 1 | **Final Design Review** |  | 14d | 2020-09-16 | 2020-10-05 |  | 16d |  |  |
| 2 | 1.1 | MS: Final Design Review | milestone | 0d | 2020-09-16 | 2020-09-16 |  | 16d | 0d | start no earlier than 2020-09-16 |
| 3 | 1.2 | Respond to FDR Recommendations |  | 14d | 2020-09-16 | 2020-10-05 | 2 | 16d | 0d |  |
| 4 | 2 | **HB650 CTL Fabrication** |  | 87d | 2020-10-06 | 2021-02-03 |  | 16d |  |  |
| 5 | 2.1 | Finalize Detailed Drawings |  | 10d | 2020-10-06 | 2020-10-19 | 3 | 16d | 0d |  |
| 6 | 2.2 | Create BOM |  | 2d | 2020-10-20 | 2020-10-21 | 5 | 16d | 0d |  |
| 7 | 2.3 | Procure, receive and inspect parts (QC) |  | 22d | 2020-10-22 | 2020-11-20 | 6 | 16d | 0d |  |
| 8 | 2.4 | Machine Parts |  | 20d | 2020-11-23 | 2020-12-18 | 7 | 16d | 0d |  |
| 9 | 2.5 | Part Preperation |  | 5d | 2020-11-23 | 2020-11-27 | 7 | 26d | 0d |  |
| 10 | 2.6 | Build (6) Bayonets |  | 5d | 2020-11-30 | 2020-12-04 | 9 | 26d | 10d |  |
| 11 | 2.7 | Staging Assembly |  | 5d | 2020-12-21 | 2020-12-25 | 10, 8 | 16d | 0d |  |
| 12 | 2.8 | Weld Internal Lines and perform Weld Inspections (QC) |  | 5d | 2020-12-28 | 2021-01-01 | 11 | 16d | 0d |  |
| 13 | 2.9 | Reverse leak Check Subcomponents (QC) |  | 5d | 2021-01-04 | 2021-01-08 | 12 | 144d |  |  |
| 14 | 2.10 | Prepare and Wrap MLI |  | 5d | 2021-01-04 | 2021-01-08 | 12 | 18d | 0d |  |
| 15 | 2.11 | Weld Vacuum Jacket |  | 5d | 2021-01-11 | 2021-01-15 | 14 | 18d | 0d |  |
| 16 | 2.12 | Weld Pipe Stands |  | 2d | 2021-01-18 | 2021-01-19 | 15 | 137d |  |  |
| 17 | 2.13 | Final Leak Check (QC) |  | 3d | 2021-01-18 | 2021-01-20 | 15 | 18d | 0d |  |
| 18 | 2.14 | Prepare Pressure Test Equipment |  | 2d | 2021-01-21 | 2021-01-22 | 17 | 134d |  |  |
| 19 | 2.15 | Draft Piping Note and Pressure Test Permit Form |  | 10d | 2021-01-04 | 2021-01-15 | 12 | 16d | 0d |  |
| 20 | 2.16 | Review Draft Piping Note and Approve Pressure Test Permit |  | 5d | 2021-01-18 | 2021-01-22 | 19 | 16d | 0d |  |
| 21 | 2.17 | Pressure Test (QC) |  | 1d | 2021-01-25 | 2021-01-25 | 20, 17 | 16d | 0d |  |
| 22 | 2.18 | Finalize Piping Note |  | 2d | 2021-01-26 | 2021-01-27 | 21 | 16d | 0d |  |
| 23 | 2.19 | Review and Approve Note |  | 5d | 2021-01-28 | 2021-02-03 | 22 | 16d | 0d |  |
| 24 | 3 | MS: CTL Fabrication Completed | milestone | 0d | 2021-02-03 | 2021-02-03 | 23 | 16d |  |  |
| 25 | 4 | MS: CMTF Cave Ready | milestone | 0d | 2021-02-26 | 2021-02-26 |  | 0d |  | start no earlier than 2021-02-26 |

| ID | WBS | Task | Type | Duration | Start | Finish | Predecessors | Total slack | Free slack |
| --- | --- | --- | --- | --- | --- | --- | --- | --- | --- |
| 26 | 5 | **HB650 CTL Installation** |  | 10d | 2021-02-26 | 2021-03-11 |  | 0d |  |
| 27 | 5.1 | Install CTL into Cave |  | 10d | 2021-02-26 | 2021-03-11 | 25, 24 | 0d |  |
| 28 | 5.2 | MS: HB650 CTL Installed | milestone | 0d | 2021-03-11 | 2021-03-11 | 27 | 0d |  |
| 29 | 6 | **U-tube Design and Fabrication** |  | 182d | 2020-10-20 | 2021-06-30 |  | 0d |  |
| 30 | 6.1 | Survey Bayonet Locations |  | 2d | 2021-03-12 | 2021-03-15 | 28 | 0d |  |
| 31 | 6.2 | U-tube Design and Preliminary Parts List |  | 20d | 2020-10-20 | 2020-11-16 | 5 | 80d | 50d |
| 32 | 6.3 | Procure, receive and inspect parts (QC) |  | 15d | 2021-01-26 | 2021-02-15 | 31, 21 | 30d | 0d |
| 33 | 6.4 | Machine Parts |  | 10d | 2021-02-16 | 2021-03-01 | 32 | 30d |  |
| 34 | 6.5 | Modify U-tube Drawings |  | 15d | 2021-03-16 | 2021-04-05 | 30 | 0d |  |
| 35 | 6.6 | Part Preperation |  | 5d | 2021-04-06 | 2021-04-12 | 32, 34 | 0d |  |
| 36 | 6.7 | Fabricate (8) U-tubes and perform Weld Inspections (QC) |  | 33d | 2021-04-13 | 2021-05-27 | 35, 33 | 0d |  |
| 37 | 6.8 | Leak Check U-tubes (QC) |  | 5d | 2021-05-28 | 2021-06-03 | 36 | 0d |  |
| 38 | 6.9 | Prepare Pressure Test Equipment |  | 1d | 2021-06-04 | 2021-06-04 | 37 | 0d |  |
| 39 | 6.10 | Draft Piping Note and Pressure Test Permit Form |  | 10d | 2021-04-06 | 2021-04-19 | 34 | 29d | 0d |
| 40 | 6.11 | Review Draft Piping Note and Approve Pressure Test Permit |  | 5d | 2021-04-20 | 2021-04-26 | 39 | 29d |  |
| 41 | 6.12 | Pressure Test (QC) |  | 1d | 2021-06-07 | 2021-06-07 | 38, 40 | 0d |  |
| 42 | 6.13 | Finalize Piping Note |  | 2d | 2021-06-08 | 2021-06-09 | 41 | 10d | 0d |
| 43 | 6.14 | Review and Approve Note |  | 5d | 2021-06-10 | 2021-06-16 | 42 | 10d |  |
| 44 | 6.15 | Install U-tubes |  | 2d | 2021-06-08 | 2021-06-09 | 41 | 0d |  |
| 45 | 6.16 | Finalize U-tube Piping Notes |  | 5d | 2021-06-10 | 2021-06-16 | 44 | 0d |  |
| 46 | 6.17 | Review and Approve Notes |  | 10d | 2021-06-17 | 2021-06-30 | 45 | 0d |  |
| 47 | 7 | **Cryogenic Safety Review** |  | 21d | 2021-07-01 | 2021-07-29 |  | 0d |  |
| 48 | 7.1 | Finalize Cryo Safety Review Documentation |  | 5d | 2021-07-01 | 2021-07-07 | 46, 43 | 0d |  |
| 49 | 7.2 | Cryo Safety Review Walkthrough and ORC Recommendation |  | 15d | 2021-07-08 | 2021-07-28 | 48 | 0d |  |
| 50 | 7.3 | Division ORC Approval |  | 1d | 2021-07-29 | 2021-07-29 | 49 | 0d |  |
| 51 | 8 | MS: Cooldown Ready | milestone | 0d | 2021-07-29 | 2021-07-29 | 50 | 0d |  |
